| id | name | startDate | endDate | priority | barScale | progress | type | parentId | dependencies |
| --- | --- | --- | --- | --- | --- | --- | --- | --- | --- |
| 1 | Rénovation de maison | 2026-06-01T00:00:00.000Z | 2026-09-21T00:00:00.000Z | medium | 1 | 0 | group |  |  |
| 2 | Périmètre et choix des finitions | 2026-06-01T00:00:00.000Z | 2026-06-15T00:00:00.000Z | high | 1 | 0 | task | 1 |  |
| 3 | Plans d'architecte | 2026-06-08T00:00:00.000Z | 2026-06-22T00:00:00.000Z | medium | 1 | 0 | task | 1 | 2 SS |
| 4 | Dépôt du permis | 2026-06-22T00:00:00.000Z | 2026-06-23T00:00:00.000Z | medium | 1 | 0 | milestone | 1 | 3 FS |
| 5 | Instruction du permis | 2026-06-22T00:00:00.000Z | 2026-07-13T00:00:00.000Z | medium | 1 | 0 | task | 1 | 4 FS |
| 6 | Commande des matériaux à long délai | 2026-06-15T00:00:00.000Z | 2026-06-22T00:00:00.000Z | high | 1 | 0 | task | 1 |  |
| 7 | Démolition | 2026-06-29T00:00:00.000Z | 2026-07-04T00:00:00.000Z | medium | 1 | 0 | task | 1 | 5 FS |
| 8 | Modifications d'ossature | 2026-07-04T00:00:00.000Z | 2026-07-11T00:00:00.000Z | medium | 1 | 0 | task | 1 | 7 FS |
| 9 | Plomberie en second œuvre | 2026-07-11T00:00:00.000Z | 2026-07-16T00:00:00.000Z | medium | 1 | 0 | task | 1 | 8 FS |
| 10 | Électricité en second œuvre | 2026-07-13T00:00:00.000Z | 2026-07-18T00:00:00.000Z | medium | 1 | 0 | task | 1 | 8 FS |
| 11 | CVC en second œuvre | 2026-07-15T00:00:00.000Z | 2026-07-19T00:00:00.000Z | medium | 1 | 0 | task | 1 | 8 FS |
| 12 | Inspections du second œuvre | 2026-07-21T00:00:00.000Z | 2026-07-23T00:00:00.000Z | medium | 1 | 0 | milestone | 1 |  |
| 13 | Plaques de plâtre | 2026-07-23T00:00:00.000Z | 2026-08-02T00:00:00.000Z | medium | 1 | 0 | task | 1 | 12 FS |
| 14 | Peinture | 2026-08-02T00:00:00.000Z | 2026-08-09T00:00:00.000Z | medium | 1 | 0 | task | 1 | 13 FS |
| 15 | Revêtement de sol | 2026-08-09T00:00:00.000Z | 2026-08-16T00:00:00.000Z | medium | 1 | 0 | task | 1 | 14 FS |
| 16 | Pose des meubles | 2026-08-16T00:00:00.000Z | 2026-08-21T00:00:00.000Z | medium | 1 | 0 | task | 1 | 15 FS |
| 17 | Gabarit du plan de travail | 2026-08-21T00:00:00.000Z | 2026-08-22T00:00:00.000Z | medium | 1 | 0 | milestone | 1 | 16 FS |
| 18 | Pose du plan de travail | 2026-08-31T00:00:00.000Z | 2026-09-02T00:00:00.000Z | medium | 1 | 0 | task | 1 | 17 FS |
| 19 | Plomberie et éclairage | 2026-09-02T00:00:00.000Z | 2026-09-09T00:00:00.000Z | medium | 1 | 0 | task | 1 |  |
| 20 | Liste des réserves et clôture | 2026-09-09T00:00:00.000Z | 2026-09-21T00:00:00.000Z | medium | 1 | 0 | task | 1 |  |
